# ADUCCIÓN BALBOA

Schedule from MS Project, 2026-05-12 to 2026-10-08, costs in $.

## Calendars

- Corrido: Mon-Sun 07:00-12:00, 14:00-17:00.

## Schedule

| ID | WBS | Task | Type | Duration | Start | Finish | Predecessors | Total slack | Free slack | Cost |
| --- | --- | --- | --- | --- | --- | --- | --- | --- | --- | --- |
| 1 | 1 | INICIO | milestone | 0d | 2026-05-12 | 2026-05-12 |  | 0d |  |  |
| 2 | 2 | **PRELIMINARES** |  | 150d | 2026-05-12 | 2026-10-08 |  | 0d |  | 124,869,883 |
| 3 | 2.1 | LOCALIZACIÓN Y REPLANTEO DE LÍNEA |  | 7d | 2026-05-12 | 2026-05-18 | 1 | 0d |  | 23,211,250 |
| 4 | 2.2 | LOCALIZACIÓN Y REPLANTEO DE OBRA |  | 7d | 2026-05-12 | 2026-05-18 | 1 | 143d |  | 112,454 |
| 5 | 2.3 | ALQUILER DE ALMACEN/CAMPAMENTO |  | 150d | 2026-05-12 | 2026-10-08 | 1 | 0d |  | 4,110,174 |
| 6 | 2.4 | CERRAMIENTO PROVISIONAL CON DELINEADOR TUBULAR TIPO COLOMBINA Y MALLA PLÁSTICA DE CONSTRUCCIÓN H=1.2M, INCLUYE ACARREO HORIZONTAL EN OBRA |  | 143d | 2026-05-19 | 2026-10-08 | 3 | 0d |  | 12,527,289 |
| 7 | 2.5 | CUBIERTA PROVISIONAL POLETILENO CAL 4 Y GUADUA |  | 143d | 2026-05-19 | 2026-10-08 | 6SS | 0d |  | 67,871,660 |
| 8 | 2.6 | ROCERÍA Y LIMPIEZA |  | 15d | 2026-05-22 | 2026-06-05 | 3SS+10d | 5d | 0d | 962,055 |
| 9 | 2.7 | CORTE DE PAVIMENTO CON CORTADORA AUTOPROPULSADA |  | 130d | 2026-05-26 | 2026-10-02 | 6SS+7d | 0d |  | 16,075,001 |
| 10 | 3 | **DEMOLICIONES** |  | 130d | 2026-05-29 | 2026-10-05 |  | 0d |  | 40,360,679 |
| 11 | 3.1 | DEMOLICIÓN MANUAL DE PAVIMENTO FLEXIBLE |  | 130d | 2026-05-29 | 2026-10-05 | 9SS+3d | 0d |  | 40,360,679 |
| 12 | 4 | **MOVIMIENTO DE TIERRA** |  | 124d | 2026-06-05 | 2026-10-06 |  | 0d |  | 1,141,067,893 |
| 13 | 4.1 | EXCAVACIÓN MANUAL EN MATERIAL COMÚN 0 - 2 M |  | 120d | 2026-06-05 | 2026-10-02 | 11SS+7d | 0d |  | 138,847,579 |
| 14 | 4.2 | EXCAVACIÓN EN MATERIAL CONGLOMERADO 0 - 2 M |  | 120d | 2026-06-05 | 2026-10-02 | 11SS+7d | 6d |  | 160,966,370 |
| 15 | 4.3 | EXCAVACION EN MATERIAL CONGLOMERADO PARA CAISSON 0 - 6 m |  | 30d | 2026-06-06 | 2026-07-05 | 8 | 5d | 0d | 5,867,852 |
| 16 | 4.4 | ENTIBADO DISCONTINUO EN MADERA (TIPO 1A) |  | 120d | 2026-06-08 | 2026-10-05 | 13SS+3d | 3d |  | 27,942,587 |
| 17 | 4.5 | SUMINISTRO Y COLOCACIÓN DE ARENA GRUESA PARA SOPORTE Y PROTECCION DE TUBERÍAS |  | 110d | 2026-06-12 | 2026-09-29 | 13SS+7d | 0d |  | 54,026,849 |
| 18 | 4.6 | LLENO COMPACTADO CON MATERIAL DEL SITIO |  | 100d | 2026-06-24 | 2026-10-01 | 27SS+5d | 0d |  | 67,367,401 |
| 19 | 4.7 | LLENO COMPACTADO CON MATERIAL GRANULAR TRANSPORTADO - AFIRMADO, INCLUYE SOBREACARREO HORIZONTAL EN OBRA |  | 100d | 2026-06-29 | 2026-10-06 | 18SS+5d | 0d |  | 169,528,699 |
| 20 | 4.8 | BASE GRANULAR, COMPACTACIÓN MECÁNICA |  | 90d | 2026-07-09 | 2026-10-06 | 21SS+5d | 2d |  | 124,058,920 |
| 21 | 4.9 | SUB-BASE GRANULAR, COMPACTACIÓN MECÁNICA |  | 90d | 2026-07-04 | 2026-10-01 | 19SS+5d | 0d |  | 121,263,221 |
| 22 | 4.10 | CARGUE Y RETIRO DE MATERIAL SOBRANTE (A BOTADERO AUTORIZADO - PEREIRA RISARALDA) |  | 115d | 2026-06-12 | 2026-10-04 | 13SS+7d | 4d | 0d | 245,346,580 |
| 23 | 4.11 | DISPOSICIÓN FINAL EN BOTADERO AUTORIZADO - PEREIRA RISARALDA |  | 115d | 2026-06-12 | 2026-10-04 | 22SS | 4d |  | 25,851,835 |
| 24 | 5 | **PAVIMENTOS** |  | 90d | 2026-07-11 | 2026-10-08 |  | 0d |  | 339,955,323 |
| 25 | 5.1 | PAVIMENTO MEZCLA ASFALTICA MDC 19 (INCLUYE CILINDRO COMPACTADOR VIBRATORIO Y BOBCAT) |  | 90d | 2026-07-11 | 2026-10-08 | 21SS+7d | 0d |  | 339,955,323 |

| ID | WBS | Task | Duration | Start | Finish | Predecessors | Total slack | Free slack | Cost |
| --- | --- | --- | --- | --- | --- | --- | --- | --- | --- |
| 26 | 6 | **SUMINISTRO E INSTALACIÓN DE TUBERÍAS Y ACCESORIOS** | 105d | 2026-06-19 | 2026-10-01 |  | 0d |  | 1,209,548,392 |
| 27 | 6.1 | SUMINISTRO E INSTALACIÓN DE TUBERÍA PEAD PN12.5 DN 200 mm (Ø8"), INCLUYE TERMOFUSION | 105d | 2026-06-19 | 2026-10-01 | 17SS+7d | 0d |  | 358,830,137 |
| 28 | 6.2 | SUMINISTRO E INSTALACIÓN DE TUBERÍA PEAD PN16 DN 200 mm (Ø8"), INCLUYE TERMOFUSION | 105d | 2026-06-19 | 2026-10-01 | 17SS+7d | 7d |  | 804,735,632 |
| 29 | 6.3 | CODO 45° PEAD PN16 DN 200 mm (Ø8") | 105d | 2026-06-19 | 2026-10-01 | 17SS+7d | 7d |  | 5,897,519 |
| 30 | 6.4 | TEE REDUCIDA HD Ø8" x Ø4", EXTREMO BRIDA | 105d | 2026-06-19 | 2026-10-01 | 17SS+7d | 7d |  | 8,361,529 |
| 31 | 6.5 | BRIDA METÁLICA Ø8" | 105d | 2026-06-19 | 2026-10-01 | 17SS+7d | 7d |  | 3,451,609 |
| 32 | 6.6 | PORTABRIDA PEAD PN 16 DN 200 mm (Ø8") | 105d | 2026-06-19 | 2026-10-01 | 17SS+7d | 7d |  | 6,129,980 |
| 33 | 6.7 | ADAPTADOR HD Ø8", EXTREMO BRIDA X UNIVERSAL | 105d | 2026-06-19 | 2026-10-01 | 17SS+7d | 7d |  | 4,761,464 |
| 34 | 6.8 | VÁLVULA DE COMPUERTA Ø4", EXTREMO BRIDA | 105d | 2026-06-19 | 2026-10-01 | 17SS+7d | 7d |  | 6,181,123 |
| 35 | 6.9 | VENTOSA TRIPLE ACCIÓN Ø4", EXTREMO BRIDA | 105d | 2026-06-19 | 2026-10-01 | 17SS+7d | 7d |  | 11,199,399 |
| 36 | 7 | **ACERO DE REFUERZO** | 80d | 2026-06-12 | 2026-08-30 |  | 39d |  | 21,894,297 |
| 37 | 7.1 | SUMINISTRO E INSTALACIÓN DE ACERO Fy = 60.000 PSI D > 1/4" | 80d | 2026-06-12 | 2026-08-30 | 13SS+7d | 39d | 0d | 21,894,297 |
| 38 | 8 | **OBRAS EN CONCRETO** | 79d | 2026-06-17 | 2026-09-03 |  | 24d |  | 46,902,450 |
| 39 | 8.1 | CAJA DE VÁLVULA VENTOSA DE 1.5 x 1.3 x 1.52 M, EN CONCRETO F'C 28 MPA (4000 PSI), NO INCLUYE REFUERZO | 45d | 2026-06-17 | 2026-07-31 | 37SS+5d | 39d | 0d | 8,617,498 |
| 40 | 8.2 | CONCRETO PARA SILLETAS, ATRAQUES Y ANCLAJES (CONCRETO 21 MPA) | 45d | 2026-06-17 | 2026-07-31 | 37SS+5d | 69d |  | 1,729,582 |
| 41 | 8.3 | CONCRETO PARA PEDESTALES DE APOYO DE VIADUCTO F'C 28 MPA (4000 PSI), NO INCLUYE REFUERZO | 30d | 2026-08-05 | 2026-09-03 | 42 | 5d | 0d | 12,564,852 |
| 42 | 8.4 | CONCRETO PARA CAISSONS F'C 28 MPA (4000 PSI), INCLUYE ANILLO DE PROTECCIÓN, NO INCLUYE REFUERZO | 30d | 2026-07-06 | 2026-08-04 | 15 | 5d | 0d | 23,990,518 |
| 43 | 9 | **VARIOS** | 30d | 2026-08-01 | 2026-08-30 |  | 39d |  | 6,202,401 |
| 44 | 9.1 | TAPA EN LAMINA DE ALFAJOR PARA CAJA DE VALVULA DE CORTE Y VENTOSAS 0.70 X 1.15 M | 30d | 2026-08-01 | 2026-08-30 | 39 | 39d |  | 6,202,401 |
| 45 | 10 | **VIADUCTOS** | 30d | 2026-09-04 | 2026-10-03 |  | 5d |  | 129,312,358 |
| 46 | 10.1 | SUMINISTRO E INSTALACIÓN DE ACERO ESTRUCTURAL PARA PERFILES TIPO H (HEA 240) DE VIADUCTO (INCLUYE ACABADO EN ANTICORROSIVO Y PINTURA) | 30d | 2026-09-04 | 2026-10-03 | 41 | 5d |  | 43,663,568 |
| 47 | 10.2 | SUMINISTRO E INSTALACIÓN DE ACERO ESTRUCTURAL PARA LAMINAS Y PLATINAS DE VIADUCTO (INCLUYE ACABADO EN ANTICORROSIVO Y PINTURA) | 30d | 2026-09-04 | 2026-10-03 | 41 | 5d |  | 59,701,490 |
| 48 | 10.3 | SUMINISTRO E INSTALACIÓN DE CABLE ESTRUCTURAL ALQUITRANADO 6X19W D=1.1/4" (INCLUYE IZAJE) | 30d | 2026-09-04 | 2026-10-03 | 41 | 5d |  | 25,947,300 |
| 49 | 11 | **SEÑALIZACIÓN Y SEGURIDAD VIAL** | 143d | 2026-05-19 | 2026-10-08 |  | 0d |  | 148,358,551 |
| 50 | 11.1 | BARRERA TIPO MALETIN PARA TRÁFICO (1.5X0.55X0.45) | 143d | 2026-05-19 | 2026-10-08 | 3 | 0d |  | 47,976,629 |
| 51 | 11.2 | SEÑAL VIAL VERTICAL REFLECTIVA TIPO PARAL TEMPORAL | 143d | 2026-05-19 | 2026-10-08 | 3 | 0d |  | 8,520,348 |
| 52 | 11.3 | PALETEROS | 143d | 2026-05-19 | 2026-10-08 | 3 | 0d |  | 91,861,574 |

| ID | WBS | Task | Type | Duration | Start | Finish | Predecessors | Total slack | Cost |
| --- | --- | --- | --- | --- | --- | --- | --- | --- | --- |
| 53 | 12 | **IMPLEMENTACIÓN DE PLANES** |  | 150d | 2026-05-12 | 2026-10-08 |  | 0d | 41,101,743 |
| 54 | 12.1 | IMPLEMENTACIÓN Y SEGUIMIENTO AL PLAN DE GESTIÓN SOCIAL |  | 150d | 2026-05-12 | 2026-10-08 | 1 | 0d | 13,700,581 |
| 55 | 12.2 | IMPLEMENTACIÓN Y SEGUIMIENTO AL PLAN DE GESTIÓN AMBIENTAL |  | 150d | 2026-05-12 | 2026-10-08 | 1 | 0d | 13,700,581 |
| 56 | 12.3 | IMPLEMENTACIÓN Y SEGUIMIENTO AL PLAN DE GESTIÓN EN SEGURIDAD Y SALUD |  | 150d | 2026-05-12 | 2026-10-08 | 1 | 0d | 13,700,581 |
| 57 | 13 | FIN | milestone | 0d | 2026-10-08 | 2026-10-08 | 7, 16, 20, 23, 25, 28, 29, 30, 31, 32, 33, 34, 35, 40, 44, 46, 47, 48, 50, 51, 52, 54, 55, 56 | 0d |  |
